# Esp. Gerencia - Ing. Juan Carlos

Schedule from MS Project, 2023-06-05 to 2024-07-22, costs in $.

## Calendars

- Copia de Estándar: Mon-Fri 07:00-12:00, 14:00-17:00; Sat 07:00-12:00; Sun off.

## Resources

| Resource | Group | Unit | Rate | Cost per use |
| --- | --- | --- | --- | --- |
| Analista Social | Profesionales |  |  | 5000000 |
| Laboratorista Hidraulico | Profesionales |  |  | 10000000 |
| Topografo | Profesionales |  |  | 10000000 |
| Especialista Estructural | Profesionales |  |  | 30000000 |
| Cuadrilla de Topografia | Mano de Obra |  | 107910 |  |
| Cuadrilla de Descapote | Mano de Obra |  | 279640 |  |
| Cuadrilla de Excavacion | Mano de Obra |  | 40939.8 |  |
| Cuadrilla de Relleno | Mano de Obra |  | 175452 |  |
| Equipo Topografico | Herr & Equipos |  | 46247.1 |  |
| Herramientas menores de Descapote | Herr & Equipos |  | 11651.7 |  |
| Herramientas menores de Excavacion | Herr & Equipos |  | 1705.83 |  |
| Herramientas menores de Rellenos | Herr & Equipos |  | 7310.5 |  |
| Concreto 2500Psi Para Solado | Material | M3 |  | 3970008 |
| Concreto 3000Psi Para Zapata, Incluye Transportes. | Material | M3 |  | 38761096 |
| Concreto 3000Psi Para Pedestal, Incluye Flanche En Platina Acero 3/16" Con Soldadura 6011 Y Pernos De 3/8" L=40cm | Material | UND |  | 16195507 |
| Concreto 3000Psi Para Columnas | Material | M3 |  | 5058665 |
| Concreto 3000 Psi Para Losa | Material | M2 |  | 5746744 |
| Concreto Simple 2500Psi Para Comederos, Incluye Placa De Fondo Y Transportes | Material | UND |  | 2916239 |
| Formaleta E Insumos Menores Para Solado De Limpieza En Concreto 2500Psi | Material | M3 |  | 700590 |
| Formaleta E Insumos Menores Para Zapata En Concreto 3000 Psi, Incluye Transportes. | Material | M3 |  | 6840193 |
| Formaleta E Insumos Menores Para Pedestal En Concreto 3000Psi | Material | UND |  | 2858031 |
| Formaleta E Insumos Menores Para Columnas En Concreto 3000Psi | Material | M3 |  | 1686222 |
| Formaleta E Insumos Menores Para Losa De Concreto 3000Psi | Material | M2 |  | 1014131 |
| Formaleta E Insumos Menores Para Comederos En Concreto 2500Psi, Incluye Transportes | Material | UND |  | 514630 |
| Cuadrilla De Solado De Limpieza | Mano de Obra |  | 29261.5 |  |
| Cuadrilla De Zapata En Concreto De 3000 Psi | Mano de Obra |  | 207128 |  |
| Cuadrilla De Pedestal En Concreto De 3000 Psi | Mano de Obra |  | 129816 |  |
| Cuadrilla De Columnas En Concreto De 3000 Psi | Mano de Obra |  | 36763.6 |  |
| Cuadrilla De Losa De Concreto De 3000 Psi | Mano de Obra |  | 30708.9 |  |
| Cuadrilla De Comederos En Concreto Simple | Mano de Obra |  | 14384.8 |  |
| Herramientas Menores De Solado De Limpieza | Herr & Equipos |  | 1170.46 |  |
| Herramientas Menores De Zapata En Concreto De 3000 Psi | Herr & Equipos |  | 8285.12 |  |
| Herramientas Menores De Pedestal En Concreto De 3000 Psi | Herr & Equipos |  | 5192.64 |  |
| Herramientas Menores De Columnas En Concreto De 3000 Psi | Herr & Equipos |  | 1470.54 |  |
| Herramientas Menores De Losa De Concreto De 3000 Psi | Herr & Equipos |  | 1228.36 |  |
| Herramientas Menores De Comederos En Concreto Simple | Herr & Equipos |  | 575.39 |  |
| Acero De Refuerzo Fy=60000 Psi, Incluye Alambre Negro | Material | KG |  | 112780432 |
| Cuadrilla De Corte, Figuracion y Armado de Acero De Refuerzo | Mano de Obra |  | 100939 |  |
| Herramientas Menores De Corte, Figuracion y Armado de Acero De Refuerzo | Herr & Equipos |  | 4037.56 |  |
| Lamina De Zinc Cal 34 De Acesco | Material | M2 |  | 65014397 |
| Cuadrilla De Estructura De Cubierta | Mano de Obra |  | 177183 |  |
| Herramientas Menores De Estructura De Cubierta | Herr & Equipos |  | 7087.33 |  |
| Madera Inmunizada Para Vigas De Soporte De Cubierta En Teja De Zinc | Material | UND |  | 72422418 |
| Platinas De Fijación En Láminas De E=1/4" | Material | UND |  | 16971845 |
| Madera Inmunizada Para Columnas De Soporte De Cubierta En Teja De Zinc | Material | UND |  | 61350499 |
| Cuadrilla De Estructura Vigas De Soporte De Cubierta | Mano de Obra |  | 303649 |  |
| Cuadrilla De Estructura Fijación De Platinas De Cubierta | Mano de Obra |  | 71710.4 |  |
| Cuadrilla De Estructura Columnas De Soporte De Cubierta | Mano de Obra |  | 222931 |  |
| Herramientas Menores De Viga de Soporte De Cubierta | Herr & Equipos |  | 12146 |  |
| Herramientas Menores De Fijacion de Platinas De Cubierta | Herr & Equipos |  | 2868.42 |  |
| Herramientas Menores De Columnas de Soporte De Cubierta | Herr & Equipos |  | 8917.22 |  |
| Malla Tipo Gavión, Incluye Transporte | Material | ML |  | 67974883 |
| Postes De Madera H=1,60 M Libre, Incluye Transporte | Material | UND |  | 11995568 |
| Puerta En Madera Para Cerramiento 1.60 M X 1 M, Incluye Transporte | Material | UND |  | 1725792 |
| Cuadrilla De Cerramiento En Malla Tipo Gavión | Mano de Obra |  | 272428 |  |
| Cuadrilla De Puerta En Madera Para Cerramiento | Mano de Obra |  | 11758.2 |  |
| Cuadrilla De Suministro, Transporte E Instalación De Bebedero Plástico | Mano de Obra |  | 13288.7 |  |
| Cuadrilla De Conexiones Hidraulicas | Mano de Obra |  | 6595.71 |  |
| Herramientas Menores De Cerramiento En Malla Tipo Gavión | Herr & Equipos |  | 10897.1 |  |
| Herramientas Menores De Puerta En Madera Para Cerramiento | Herr & Equipos |  | 470.33 |  |
| Herramientas Menores De Instalación De Bebedero Plástico | Herr & Equipos |  | 1594.64 |  |
| Herramientas Menores De Conexiones Hidraulicas | Herr & Equipos |  | 226.14 |  |
| Accesorios Para Conexión Hidraulicas A Tanque De 1000 Litros | Material | UND |  | 4386004 |
| Divisiones Para El Transportes Y Manejo De Los Ovinos, Incluye Transporte | Material | M2 |  | 54428874 |
| Lava Patas Para Sistema De Productividad Caprina, Incluye Transporte | Material | ML |  | 10082072 |
| Bebedero Plástico De Capacidad 250 Lt, Incluye Transporte | Material | UND |  | 3776113 |
| Tanque Plástico De 1000lts Incluye Accesorios y Transporte | Material | UND |  | 20336292 |
| Cuadrilla De Suministro, Transporte E Instalación Tanque Plástico De 1000lts | Mano de Obra |  | 17891.6 |  |
| Cuadrilla De Suministro, Transporte E Instalación De Divisiones | Mano de Obra |  | 95771.5 |  |
| Cuadrilla De Suministro, Transporte E Instalación De Lava Patas | Mano de Obra |  | 17740.1 |  |
| Herramientas Menores De Instalación Tanque Plástico De 1000lts | Herr & Equipos |  | 2146.99 |  |
| Herramientas Menores De Instalación De Divisiones | Herr & Equipos |  | 11492.6 |  |
| Herramientas Menores De Instalación De Lava Patas | Herr & Equipos |  | 2128.82 |  |
| Profesional Conferencista | Material |  |  | 700000 |
| Escarapelas | Material | UND |  | 120000 |
| Libro de trabajo | Material | UND |  | 600000 |
| Lapiceros | Material | UND |  | 36000 |
| Refrigerio | Material | GLB |  | 960000 |
| Punto de hidratación y café | Material | GLB |  | 100000 |
| Sonido y ambientación | Material | GLB |  | 400000 |
| Alquiler de VideoBeam | Material | GLB |  | 120000 |
| Cartillas del proceso de formación, tamaño media carta, propalcote a todo color. | Material | UND |  | 600000 |
| Papelería varios | Material | GLB |  | 100000 |
| Sal Mineralizada Marca Ganasal Al 6% X 40kg | Material | UND |  | 464750 |
| Desparasitante Albendazol Oral | Material | UND |  | 114400 |
| Vitamina Complejo B Velamil | Material | UND |  | 257.4 |
| Insepticida Curagan | Material | UND |  | 57200 |
| Antibiotico Tylan | Material | UND |  | 71500 |
| Lazo De Manejo Para Sujetar El Animal | Material | UND |  | 35750 |
| Jeringa Marca Laura | Material | UND |  | 50050 |
| Bolsa De Liga De Castración Marca Laura | Material | UND |  | 42900 |
| Yodo Para Curacion De Ombligo | Material | UND |  | 35750 |
| Mosquisida Marca Ganabaño (Cipermitrina) | Material | UND |  | 42900 |
| Animal Caprino Hembra Para Productividad | Material | UND |  | 32340000 |
| Animal Ovino Caprino Padrote Para Productividad | Material | UND |  | 5000000 |
| Ensilaje De Maiz X 50 Kilos | Material | UND |  | 3360000 |
| Melaza X Bolsa 40 Kilos | Material | UND |  | 550000 |
| Profesional Conferencista Especialista Pecuario | Material |  |  | 700000 |

## Schedule

| ID | WBS | Task | Type | Duration | Start | Finish | Predecessors | Total slack | Free slack | Constraint | Resources | Work | Cost | Vr. Parcial | Vr. Total (11 Unidades) | Cantidad | Vr. Unitario |
| --- | --- | --- | --- | --- | --- | --- | --- | --- | --- | --- | --- | --- | --- | --- | --- | --- | --- |
| 1 | 1 | **Fortalecimiento para la producción pecuaria de especies menores (ovino) en la comunidad de Cerrodeo del municipio de Barrancas, La Guajira.** |  | 332.65d | 2023-06-05 | 2024-07-22 |  | 0d |  |  |  | 7775.2h | 1,300,180,448.07 |  |  |  |  |
| 2 | 1.1 | Inicio | milestone | 0d | 2023-06-05 | 2023-06-05 | 3SS | 356.62d |  |  |  |  |  |  |  |  |  |
| 3 | 1.2 | **Etapa Precontractual** |  | 46.3d | 2023-06-05 | 2023-08-01 |  | 0d |  |  |  | 751.2h | 65,000,000 |  |  |  |  |
| 4 | 1.2.1 | **Etapa De Estudios Y Diseños** |  | 39.2d | 2023-06-05 | 2023-07-22 |  | 7.1d |  |  |  | 420.8h | 55,000,000 |  |  |  |  |
| 5 | 1.2.1.1 | Analizar De Ambiente Para Determinar Los Materiales Viables Para El Sector. |  | 4.2d | 2023-06-05 | 2023-06-09 |  | 7.1d | 5d |  | Analista Social | 33.6h | 5,000,000 |  |  |  |  |
| 6 | 1.2.1.2 | Realizar Ensayos De Laboratorio Sobre La Potabilidad Del Agua |  | 9.2d | 2023-06-05 | 2023-06-15 |  | 2.1d | 0d |  | Laboratorista Hidraulico | 73.6h | 10,000,000 |  |  |  |  |
| 7 | 1.2.1.3 | Realizar Estudios Topográfico En El Área Proyectada |  | 9.2d | 2023-06-05 | 2023-06-15 |  | 2.1d | 0d |  | Topografo | 73.6h | 10,000,000 |  |  |  |  |
| 8 | 1.2.1.4 | Realizar Estudios Técnicos Y Estructurales Para La Construcción De Los Apriscos |  | 30d | 2023-06-15 | 2023-07-22 | 5, 6, 7 | 2.1d |  |  | Especialista Estructural | 240h | 30,000,000 |  |  |  |  |
| 9 | 1.2.2 | **Socializaciones Precontractuales** |  | 41.3d | 2023-06-10 | 2023-08-01 |  | 0d |  |  |  | 330.4h | 10,000,000 |  |  |  |  |
| 10 | 1.2.2.1 | Contemplar Las Observaciones De Personas De Interés De La Comunidad |  | 15d | 2023-06-10 | 2023-06-29 |  | 0d |  | start no earlier than 2023-06-10 | Analista Social | 120h | 5,000,000 |  |  |  |  |
| 11 | 1.2.2.2 | Realizar La Socialización Del Proyecto Con La Población |  | 26.3d | 2023-06-29 | 2023-08-01 | 10 | 0d |  |  | Analista Social | 210.4h | 5,000,000 |  |  |  |  |
| 12 | 1.3 | **Construcción De 11 Apriscos Con Cerramiento Y Con Tanques Elevados De 1000 L En La Zona Indígena** |  | 186.2d | 2023-08-01 | 2024-03-19 |  | 0d |  |  |  | 5632h | 1,185,542,990.67 |  |  |  |  |
| 13 | 1.3.1 | **Preeliminares Aprisco** |  | 30.1d | 2023-08-01 | 2023-09-07 |  | 0d |  |  |  | 481.6h | 48,091,797.54 | $ 4.371.981,60 | $ 48.091.797,60 |  |  |
| 14 | 1.3.1.1 | Localizacion Y Replanteo Topográfico Sobre Terreno Natural |  | 20.1d | 2023-08-01 | 2023-08-25 | 8, 11 | 0d |  |  | Cuadrilla de Topografia; Equipo Topografico | 321.6h | 24,788,432.74 | $ 2.253.493,90 | $ 24.788.432,90 | 462,35 | $ 4.874,00 |
| 15 | 1.3.1.2 | Desmonte Y Descapote Manual Exp Hasta 0.15mts |  | 10d | 2023-08-25 | 2023-09-07 | 14 | 0d |  |  | Cuadrilla de Descapote; Herramientas menores de Descapote | 160h | 23,303,364.8 | $ 2.118.487,70 | $ 23.303.364,70 | 462,35 | $ 4.582,00 |
| 16 | 1.3.2 | **Excavaciones Y Rellenos** |  | 30.8d | 2023-09-07 | 2023-10-16 |  | 0d |  |  |  | 492.8h | 21,717,233.82 | $ 1.974.293,97 | $ 21.717.233,72 |  |  |
| 17 | 1.3.2.1 | Excavacion Manual |  | 20.8d | 2023-09-07 | 2023-10-03 | 15 | 0d |  |  | Cuadrilla de Excavacion; Herramientas menores de Excavacion | 332.8h | 7,096,237.82 | $ 645.112,51 | $ 7.096.237,61 | 15,08 | $ 42.768,00 |
| 18 | 1.3.2.2 | Relleno Con Material Seleccionado "Incluye Suministro, Compactación Y Transporte Desde Cantera" |  | 10d | 2023-10-03 | 2023-10-16 | 17 | 0d |  |  | Cuadrilla de Relleno; Herramientas menores de Rellenos | 160h | 14,620,996 | $ 1.329.181,46 | $ 14.620.996,06 | 6,11 | $ 217.453,00 |
| 19 | 1.3.3 | **Cimentacion Y Estructuras De Concreto** |  | 63.7d | 2023-10-16 | 2024-01-03 |  | 0d |  |  |  | 1019.2h | 125,380,895.88 | $ 11.398.263,13 | $ 125.380.894,46 |  |  |
| 20 | 1.3.3.1 | Solado De Limpieza En Concreto De F''c=17,5 Mpa |  | 8.7d | 2023-10-16 | 2023-10-26 | 18 | 0d |  |  | Cuadrilla De Solado De Limpieza; Herramientas Menores De Solado De Limpieza; Formaleta E Insumos Menores Para Solado De Limpieza En Concreto 2500Psi [1 M3]; Concreto 2500Psi Para Solado [1 M3] | 139.2h | 6,788,659.27 | $ 617.150,85 | $ 6.788.659,35 | 0,93 | $ 661.115,00 |
| 21 | 1.3.3.2 | Zapata En Concreto De 3000 Psi F'c 21 Mpa, Incluye Transportes. |  | 12d | 2023-10-26 | 2023-11-10 | 20 | 0d |  |  | Cuadrilla De Zapata En Concreto De 3000 Psi; Formaleta E Insumos Menores Para Zapata En Concreto 3000 Psi, Incluye Transportes. [1 M3]; Herramientas Menores De Zapata En Concreto De 3000 Psi; Concreto 3000Psi Para Zapata, Incluye Transportes. [1 M3] | 192h | 66,280,943.89 | $ 6.025.540,32 | $ 66.280.943,52 | 7,63 | $ 789.510,00 |
| 22 | 1.3.3.3 | Pedestal En Concreto De 3000 Psi (0.40x0.40 Mts) H=0.40 "Incluye Flanche En Platina Acero 3/16" Con Soldadura 6011 Y Pernos De 3/8" L=40cms Con Arandela Y Tuerca" |  | 8d | 2023-11-10 | 2023-11-20 | 21 | 0d |  |  | Cuadrilla De Pedestal En Concreto De 3000 Psi; Formaleta E Insumos Menores Para Pedestal En Concreto 3000Psi [1 UND]; Herramientas Menores De Pedestal En Concreto De 3000 Psi; Concreto 3000Psi Para Pedestal, Incluye Flanche En Platina Acero 3/16" Con Soldadura 6011 Y Pernos De 3/8" L=40cm [1 UND] | 128h | 27,694,094.84 | $ 2.517.645,00 | $ 27.694.095,00 | 15,00 | $ 167.843,00 |
| 23 | 1.3.3.4 | Columnas En Concreto De 3000 Psi, F'c=21 Mpa |  | 10d | 2023-11-20 | 2023-12-02 | 22 | 0d |  |  | Cuadrilla De Columnas En Concreto De 3000 Psi; Formaleta E Insumos Menores Para Columnas En Concreto 3000Psi [1 M3]; Herramientas Menores De Columnas En Concreto De 3000 Psi; Concreto 3000Psi Para Columnas [1 M3] | 160h | 9,803,614.92 | $ 891.237,70 | $ 9.803.614,70 | 0,71 | $ 1.254.381,00 |
| 24 | 1.3.3.5 | Losa De Concreto De 3000 Psi F'c=21 Mpa Exp: 0.12 Mts Para Soporte Del Tanque Elevado |  | 12d | 2023-12-02 | 2023-12-18 | 23 | 0d |  |  | Cuadrilla De Losa De Concreto De 3000 Psi; Formaleta E Insumos Menores Para Losa De Concreto 3000Psi [1 M2]; Herramientas Menores De Losa De Concreto De 3000 Psi; Concreto 3000 Psi Para Losa [1 M2] | 192h | 9,826,853.65 | $ 893.350,26 | $ 9.826.852,86 | 5,45 | $ 164.068,00 |
| 25 | 1.3.3.6 | Comederos En Concreto Simple De F'c=17,5 Mpa Incluye Placa De Fondo Y Transportes |  | 13d | 2023-12-18 | 2024-01-03 | 24 | 0d |  |  | Cuadrilla De Comederos En Concreto Simple; Formaleta E Insumos Menores Para Comederos En Concreto 2500Psi, Incluye Transportes [1 UND]; Herramientas Menores De Comederos En Concreto Simple; Concreto Simple 2500Psi Para Comederos, Incluye Placa De Fondo Y Transportes [1 UND] | 208h | 4,986,729.31 | $ 453.339,00 | $ 4.986.729,00 | 1,00 | $ 453.339,00 |

| ID | WBS | Task | Duration | Start | Finish | Predecessors | Total slack | Free slack | Resources | Work | Cost | Vr. Parcial | Vr. Total (11 Unidades) | Cantidad | Vr. Unitario |
| --- | --- | --- | --- | --- | --- | --- | --- | --- | --- | --- | --- | --- | --- | --- | --- |
| 26 | 1.3.4 | **Aceros** | 60.9d | 2023-10-16 | 2023-12-29 |  | 64.4d |  |  | 974.4h | 163,925,046.14 | $ 14.902.276,97 | $ 163.925.046,69 |  |  |
| 27 | 1.3.4.1 | Suministro, Transporte, Figurado E Instalación De Acero De Refuerzo Fy=60000 Psi | 60.9d | 2023-10-16 | 2023-12-29 | 18 | 64.4d |  | Cuadrilla De Corte, Figuracion y Armado de Acero De Refuerzo; Herramientas Menores De Corte, Figuracion y Armado de Acero De Refuerzo; Acero De Refuerzo Fy=60000 Psi, Incluye Alambre Negro [1 KG] | 974.4h | 163,925,046.14 | $ 14.902.276,97 | $ 163.925.046,67 | 1409,73 | $ 10.571,00 |
| 28 | 1.3.5 | **Cubierta** | 60.9d | 2024-01-03 | 2024-03-19 |  | 0.7d |  |  | 974.4h | 313,603,430.18 | $ 28.509.402,66 | $ 313.603.429,26 |  |  |
| 29 | 1.3.5.1 | Estructura Vertical " Columnas" En Madera Inmunizada Para Soporte De Cubierta En Teja De Zinc | 15d | 2024-01-03 | 2024-01-22 | 25 | 0.7d | 0d | Cuadrilla De Estructura Columnas De Soporte De Cubierta; Herramientas Menores De Columnas de Soporte De Cubierta; Madera Inmunizada Para Columnas De Soporte De Cubierta En Teja De Zinc [1 UND] | 240h | 89,172,236.3 | $ 8.106.567,00 | $ 89.172.237,00 | 42,60 | $ 190.295,00 |
| 30 | 1.3.5.2 | Platinas De Fijación En Nudos De La Estructura En Láminas De E=1/4" | 12.9d | 2024-01-22 | 2024-02-06 | 29 | 0.7d | 0d | Cuadrilla De Estructura Fijación De Platinas De Cubierta; Herramientas Menores De Fijacion de Platinas De Cubierta; Platinas De Fijación En Láminas De E=1/4" [1 UND] | 206.4h | 24,668,380.66 | $ 2.242.580,00 | $ 24.668.380,00 | 20,00 | $ 112.129,00 |
| 31 | 1.3.5.3 | Estructura Horizontal "Vigas" De Soporte En Madera Inmunizada Para Soporte De Cubierta En Teja De Zinc | 13d | 2024-02-06 | 2024-02-22 | 30 | 0.7d | 0d | Cuadrilla De Estructura Vigas De Soporte De Cubierta; Herramientas Menores De Viga de Soporte De Cubierta; Madera Inmunizada Para Vigas De Soporte De Cubierta En Teja De Zinc [1 UND] | 208h | 105,265,142.72 | $ 9.569.558,40 | $ 105.265.142,40 | 81,60 | $ 117.274,00 |
| 32 | 1.3.5.4 | Cubierta En Lamina De Zinc Cal 34 De Acesco O Similar | 20d | 2024-02-22 | 2024-03-19 | 31 | 0.7d |  | Cuadrilla De Estructura De Cubierta; Herramientas Menores De Estructura De Cubierta; Lamina De Zinc Cal 34 De Acesco [1 M2] | 320h | 94,497,670.5 | $ 8.590.697,26 | $ 94.497.669,86 | 138,62 | $ 61.973,00 |
| 33 | 1.3.6 | **Cerramiento, Carpinteria, Hidraulicas Y Bebederos Y Bebederos** | 61.6d | 2024-01-03 | 2024-03-19 | 25 | 0d |  |  | 1689.6h | 225,420,226.67 | $ 20.492.747,70 | $ 225.420.224,70 |  |  |
| 34 | 1.3.6.1 | Cerramiento En Malla Tipo Gavión Y Postes De Madera H=1,60 (Incluye Excavación) | 16d | 2024-01-03 | 2024-01-23 |  | 37.6d | 0d | Cuadrilla De Cerramiento En Malla Tipo Gavión; Herramientas Menores De Cerramiento En Malla Tipo Gavión; Malla Tipo Gavión, Incluye Transporte [1 ML]; Postes De Madera H=1,60 M Libre, Incluye Transporte [1 UND] | 256h | 116,236,121 | $ 10.566.920,00 | $ 116.236.120,00 | 91,00 | $ 116.120,00 |
| 35 | 1.3.6.2 | Puerta En Madera Para Cerramiento Del Aprisco H=1.60 M X 1 M | 8d | 2024-01-23 | 2024-02-01 | 34 | 37.6d |  | Cuadrilla De Puerta En Madera Para Cerramiento; Herramientas Menores De Puerta En Madera Para Cerramiento; Puerta En Madera Para Cerramiento 1.60 M X 1 M, Incluye Transporte [1 UND] | 128h | 2,508,418.14 | $ 228.038,00 | $ 2.508.418,00 | 1,00 | $ 228.038,00 |
| 36 | 1.3.6.3 | Bebedero Plástico De Capacidad 250 Lt | 4d | 2024-01-03 | 2024-01-08 |  | 49.6d | 4d | Bebedero Plástico De Capacidad 250 Lt, Incluye Transporte [1 UND]; Cuadrilla De Suministro, Transporte E Instalación De Bebedero Plástico; Herramientas Menores De Instalación De Bebedero Plástico | 64h | 4,252,380 | $ 386.580,00 | $ 4.252.380,00 | 1,00 | $ 386.580,00 |
| 37 | 1.3.6.4 | Suministro, Transporte E Instalación De Lava Patas Para Sistema De Productividad Caprina | 8d | 2024-01-03 | 2024-01-12 |  | 45.6d | 0d | Cuadrilla De Suministro, Transporte E Instalación De Lava Patas; Herramientas Menores De Instalación De Lava Patas; Lava Patas Para Sistema De Productividad Caprina, Incluye Transporte [1 ML] | 128h | 11,353,685.3 | $ 1.032.153,20 | $ 11.353.685,20 | 5,20 | $ 198.491,00 |
| 38 | 1.3.6.5 | Suministro, Transporte E Instalación De Divisiones Para El Transportes Y Manejo De Los Ovinos | 8d | 2024-01-12 | 2024-01-23 | 37, 36 | 45.6d |  | Cuadrilla De Suministro, Transporte E Instalación De Divisiones; Divisiones Para El Transportes Y Manejo De Los Ovinos, Incluye Transporte [1 M2]; Herramientas Menores De Instalación De Divisiones | 128h | 61,293,776.54 | $ 5.572.161,50 | $ 61.293.776,50 | 14,50 | $ 384.287,00 |
| 39 | 1.3.6.6 | Suministro, Transporte E Instalación Tanque Plástico De 1000lts Incluye Accesorios | 16d | 2024-02-28 | 2024-03-19 | 40 | 0d |  | Cuadrilla De Suministro, Transporte E Instalación Tanque Plástico De 1000lts; Herramientas Menores De Instalación Tanque Plástico De 1000lts; Tanque Plástico De 1000lts Incluye Accesorios y Transporte [1 UND] | 256h | 22,901,230.44 | $ 2.081.930,00 | $ 22.901.230,00 | 2,00 | $ 1.040.965,00 |
| 40 | 1.3.6.7 | Conexión Hidraulicas A Tanque De 1000 Litros | 45.6d | 2024-01-03 | 2024-02-28 |  | 0d |  | Accesorios Para Conexión Hidraulicas A Tanque De 1000 Litros [1 UND]; Cuadrilla De Conexiones Hidraulicas; Herramientas Menores De Conexiones Hidraulicas | 729.6h | 6,874,615.25 | $ 624.965,00 | $ 6.874.615,00 | 1,00 | $ 624.965,00 |
| 41 | 1.3.7 | **Costos Indirectos Del Proyecto** | 186.2d | 2023-08-01 | 2024-03-19 | 13SS | 0d |  |  |  | 287,404,360.45 |  |  |  |  |
| 42 | 1.3.7.1 | Administración | 186.2d | 2023-08-01 | 2024-03-19 |  | 0d |  |  |  | 251,478,815.4 |  |  |  |  |
| 43 | 1.3.7.2 | Imprevistos | 186.2d | 2023-08-01 | 2024-03-19 |  | 0d |  |  |  | 8,981,386.26 |  |  |  |  |
| 44 | 1.3.7.3 | Utilidad | 186.2d | 2023-08-01 | 2024-03-19 |  | 0d |  |  |  | 26,944,158.79 |  |  |  |  |
| 45 | 1.4 | **Talleres De Capacitación** | 100.15d | 2024-03-19 | 2024-07-22 | 12 | 0d |  |  | 1392h | 7,472,000 |  |  |  |  |
| 46 | 1.4.1 | **Capacitación En Buenas Prácticas En La Producción Ovino-Caprina** | 88.9d | 2024-03-19 | 2024-07-08 |  | 11.25d |  |  | 696h | 3,736,000 |  |  |  |  |
| 47 | 1.4.1.1 | Conferencista | 87d | 2024-03-21 | 2024-07-08 | 48 | 11.25d |  | Profesional Conferencista Especialista Pecuario | 696h | 700,000 |  |  |  |  |
| 48 | 1.4.1.2 | Escarapelas | 1.9d | 2024-03-19 | 2024-03-21 |  | 11.25d | 0d | Escarapelas [1 UND] |  | 120,000 |  |  |  |  |
| 49 | 1.4.1.3 | Libro De Trabajo | 1.9d | 2024-03-19 | 2024-03-21 |  | 98.25d |  | Libro de trabajo [1 UND] |  | 600,000 |  |  |  |  |
| 50 | 1.4.1.4 | Lapiceros | 1.9d | 2024-03-19 | 2024-03-21 |  | 98.25d |  | Lapiceros [1 UND] |  | 36,000 |  |  |  |  |
| 51 | 1.4.1.5 | Refrigerio | 87d | 2024-03-19 | 2024-07-05 |  | 13.15d |  | Refrigerio [1 GLB] |  | 960,000 |  |  |  |  |
| 52 | 1.4.1.6 | Punto De Hidratación Y Café | 87d | 2024-03-21 | 2024-07-08 | 48 | 11.25d |  | Punto de hidratación y café [1 GLB] |  | 100,000 |  |  |  |  |
| 53 | 1.4.1.7 | Sonido Y Ambientación | 87d | 2024-03-21 | 2024-07-08 | 48 | 11.25d |  | Sonido y ambientación [1 GLB] |  | 400,000 |  |  |  |  |
| 54 | 1.4.1.8 | Alquiler De Videobeam | 87d | 2024-03-21 | 2024-07-08 | 48 | 11.25d |  | Alquiler de VideoBeam [1 GLB] |  | 120,000 |  |  |  |  |
| 55 | 1.4.1.9 | Cartillas Del Proceso De Formación, Tamaño Media Carta, Propalcote A Todo Color. | 1.9d | 2024-03-19 | 2024-03-21 |  | 98.25d |  | Cartillas del proceso de formación, tamaño media carta, propalcote a todo color. [1 UND] |  | 600,000 |  |  |  |  |
| 56 | 1.4.1.10 | Papelería Varios | 87d | 2024-03-21 | 2024-07-08 | 48 | 11.25d |  | Papelería varios [1 GLB] |  | 100,000 |  |  |  |  |

| ID | WBS | Task | Type | Duration | Start | Finish | Predecessors | Total slack | Resources | Work | Cost |
| --- | --- | --- | --- | --- | --- | --- | --- | --- | --- | --- | --- |
| 57 | 1.4.2 | **Capacitación En Fortalecimiento Socio empresarial 30 Personas** |  | 100.15d | 2024-03-19 | 2024-07-22 |  | 0d |  | 696h | 3,736,000 |
| 58 | 1.4.2.1 | Conferencista |  | 87d | 2024-03-21 | 2024-07-22 | 59 | 0d | Profesional Conferencista | 696h | 700,000 |
| 59 | 1.4.2.2 | Escarapelas |  | 1.9d | 2024-03-19 | 2024-03-21 |  | 0d | Escarapelas [1 UND] |  | 120,000 |
| 60 | 1.4.2.3 | Libro De Trabajo |  | 1.9d | 2024-03-19 | 2024-03-21 |  | 98.25d | Libro de trabajo [1 UND] |  | 600,000 |
| 61 | 1.4.2.4 | Lapiceros |  | 1.9d | 2024-03-19 | 2024-03-21 |  | 98.25d | Lapiceros [1 UND] |  | 36,000 |
| 62 | 1.4.2.5 | Refrigerio |  | 87d | 2024-03-19 | 2024-07-05 |  | 13.15d | Refrigerio [1 GLB] |  | 960,000 |
| 63 | 1.4.2.6 | Punto De Hidratación Y Café |  | 87d | 2024-03-21 | 2024-07-08 | 59 | 11.25d | Punto de hidratación y café [1 GLB] |  | 100,000 |
| 64 | 1.4.2.7 | Sonido Y Ambientación |  | 87d | 2024-03-21 | 2024-07-08 | 59 | 11.25d | Sonido y ambientación [1 GLB] |  | 400,000 |
| 65 | 1.4.2.8 | Alquiler De Videobeam |  | 87d | 2024-03-21 | 2024-07-08 | 59 | 11.25d | Alquiler de VideoBeam [1 GLB] |  | 120,000 |
| 66 | 1.4.2.9 | Cartillas Del Proceso De Formación, Tamaño Media Carta, Propalcote A Todo Color. |  | 1.9d | 2024-03-19 | 2024-03-21 |  | 98.25d | Cartillas del proceso de formación, tamaño media carta, propalcote a todo color. [1 UND] |  | 600,000 |
| 67 | 1.4.2.10 | Papelería Varios |  | 87d | 2024-03-21 | 2024-07-08 | 59 | 11.25d | Papelería varios [1 GLB] |  | 100,000 |
| 68 | 1.5 | **Costos De Producción Ovino Caprino, Con Insumo De Animales Y Capital De Trabajo Para 3 Meses De Sostenimiento** |  | 90.3d | 2024-03-19 | 2024-07-10 | 12 | 9.85d |  |  | 42,165,457.4 |
| 69 | 1.5.1 | **Materia Prima E Insumos** |  | 90.3d | 2024-03-19 | 2024-07-10 |  | 9.85d |  |  | 42,165,457.4 |
| 70 | 1.5.1.1 | Sal Mineralizada Marca Ganasal Al 6% X 40kg |  | 90d | 2024-03-19 | 2024-07-09 |  | 10.15d | Sal Mineralizada Marca Ganasal Al 6% X 40kg [1 UND] |  | 464,750 |
| 71 | 1.5.1.2 | Desparasitante Albendazol Oral |  | 90d | 2024-03-19 | 2024-07-09 |  | 10.15d | Desparasitante Albendazol Oral [1 UND] |  | 114,400 |
| 72 | 1.5.1.3 | Vitamina Complejo B Velamil |  | 90d | 2024-03-19 | 2024-07-09 |  | 10.15d | Vitamina Complejo B Velamil [1 UND] |  | 257.4 |
| 73 | 1.5.1.4 | Insecticida Curagan |  | 90d | 2024-03-19 | 2024-07-09 |  | 10.15d | Insepticida Curagan [1 UND] |  | 57,200 |
| 74 | 1.5.1.5 | Antibiótico Tylan |  | 90d | 2024-03-19 | 2024-07-09 |  | 10.15d | Antibiotico Tylan [1 UND] |  | 71,500 |
| 75 | 1.5.1.6 | Lazo De Manejo Para Sujetar El Animal |  | 90d | 2024-03-19 | 2024-07-09 |  | 10.15d | Lazo De Manejo Para Sujetar El Animal [1 UND] |  | 35,750 |
| 76 | 1.5.1.7 | Jeringa Marca Laura |  | 90d | 2024-03-19 | 2024-07-09 |  | 10.15d | Jeringa Marca Laura [1 UND] |  | 50,050 |
| 77 | 1.5.1.8 | Bolsa De Liga De Castración Marca Laura |  | 90d | 2024-03-19 | 2024-07-09 |  | 10.15d | Bolsa De Liga De Castración Marca Laura [1 UND] |  | 42,900 |
| 78 | 1.5.1.9 | Yodo Para Curación De Ombligo |  | 90d | 2024-03-19 | 2024-07-09 |  | 10.15d | Yodo Para Curacion De Ombligo [1 UND] |  | 35,750 |
| 79 | 1.5.1.10 | Mosquicida Marca Ganabaño (Cipermetrina) |  | 90d | 2024-03-19 | 2024-07-09 |  | 10.15d | Mosquisida Marca Ganabaño (Cipermitrina) [1 UND] |  | 42,900 |
| 80 | 1.5.1.11 | Suministro De Animal Caprino Hembra Para Productividad |  | 90.3d | 2024-03-19 | 2024-07-10 |  | 9.85d | Animal Caprino Hembra Para Productividad [1 UND] |  | 32,340,000 |
| 81 | 1.5.1.12 | Suministro De Animal Ovino Caprino Padrote Para Productividad |  | 90.3d | 2024-03-19 | 2024-07-10 |  | 9.85d | Animal Ovino Caprino Padrote Para Productividad [1 UND] |  | 5,000,000 |
| 82 | 1.5.1.13 | Ensilaje De Maíz X 50 Kilos |  | 90d | 2024-03-19 | 2024-07-09 |  | 10.15d | Ensilaje De Maiz X 50 Kilos [1 UND] |  | 3,360,000 |
| 83 | 1.5.1.14 | Melaza X Bolsa 40 Kilos |  | 90d | 2024-03-19 | 2024-07-09 |  | 10.15d | Melaza X Bolsa 40 Kilos [1 UND] |  | 550,000 |
| 84 | 1.6 | Fin | milestone | 0d | 2024-07-22 | 2024-07-22 | 45, 68 | 0d |  |  |  |
